# Gant

Schedule from MS Project, 2005-01-10 to 2005-04-29.

## Calendars

- Standard: Mon-Fri 08:00-12:00, 13:00-17:00; Sat-Sun off.

## Resources

| Resource |
| --- |
| Peri |
| Peri & Mike |
| Joe & Sean |
| Sean & Mike |
| Mike |
| Sean |
| Joe |
| Sean W |
| Andrew |

## Schedule

| ID | WBS | Task | Duration | Start | Finish | Predecessors | Total slack | Free slack | Constraint | Resources | Work |
| --- | --- | --- | --- | --- | --- | --- | --- | --- | --- | --- | --- |
| 1 | 1 | **ROMP Project** | 80d? | 2005-01-10 | 2005-04-29 |  | 0d |  |  | Mike; Peri; Sean; Joe; Sean W | 6909.33h |
| 2 | 1.1 | **Web Interface Implementation** | 28d? | 2005-01-10 | 2005-02-16 |  | 0d |  |  | Peri | 1000h |
| 3 | 1.1.1 | **Controls Implementation** | 27d | 2005-01-10 | 2005-02-15 |  | 0d |  |  |  | 216h |
| 4 | 1.1.1.1 | **Pan Control** | 5d | 2005-01-10 | 2005-01-14 |  | 0d |  |  | Peri | 40h |
| 5 | 1.1.1.1.1 | Pan Control Implementation | 4d | 2005-01-10 | 2005-01-13 |  | 0d |  | start no earlier than 2005-01-10 |  |  |
| 6 | 1.1.1.1.2 | Pan Control Testing | 1d | 2005-01-14 | 2005-01-14 | 5 | 0d |  | start no earlier than 2005-01-11 |  |  |
| 7 | 1.1.1.2 | **Tilt Control** | 11d | 2005-01-17 | 2005-01-31 | 6 | 0d |  |  | Peri | 88h |
| 8 | 1.1.1.2.1 | Tilt Control Implementation | 7d | 2005-01-17 | 2005-01-25 |  | 0d |  |  |  |  |
| 9 | 1.1.1.2.2 | Tilt Control Testing | 4d | 2005-01-26 | 2005-01-31 | 8 | 0d |  |  |  |  |
| 10 | 1.1.1.3 | **Zoom Control** | 11d | 2005-02-01 | 2005-02-15 | 9 | 0d |  |  | Peri | 88h |
| 11 | 1.1.1.3.1 | Zoom Control Implementation | 7d | 2005-02-01 | 2005-02-09 |  | 0d |  | start no earlier than 2005-01-29 |  |  |
| 12 | 1.1.1.3.2 | Zoom Control Testing | 4d | 2005-02-10 | 2005-02-15 | 11 | 0d |  |  |  |  |
| 13 | 1.1.2 | **Code Review** | 1d? | 2005-02-16 | 2005-02-16 | 3 | 0d |  |  | Mike; Peri; Sean; Joe; Sean W | 40h |
| 14 | 1.1.2.1 | Controls Implementation Code Review | 1d? | 2005-02-16 | 2005-02-16 |  | 0d |  |  |  |  |
| 15 | 1.1.3 | **Mapping Implementation** | 27d | 2005-01-10 | 2005-02-15 |  | 0d |  |  | Joe; Sean | 480h |
| 16 | 1.1.3.1 | **Map Class Implementation** | 24d | 2005-01-10 | 2005-02-10 |  | 3d |  |  |  |  |
| 17 | 1.1.3.1.1 | Canvas Graphics Implementation | 7d | 2005-01-10 | 2005-01-18 |  | 3d | 0d | start no earlier than 2005-01-10 |  |  |
| 18 | 1.1.3.1.2 | Canvas Graphics Testing | 5d | 2005-01-19 | 2005-01-25 | 17 | 3d | 0d |  |  |  |
| 19 | 1.1.3.1.3 | Mapping Zoom Implementation | 7d | 2005-01-26 | 2005-02-03 | 18 | 3d | 0d |  |  |  |
| 20 | 1.1.3.1.4 | Mapping Zoom Testing | 5d | 2005-02-04 | 2005-02-10 | 19 | 3d |  |  |  |  |
| 21 | 1.1.3.2 | **Robot Class Implementation** | 3d | 2005-02-11 | 2005-02-15 |  | 0d |  |  | Joe; Sean | 48h |
| 22 | 1.1.3.2.1 | Rotation Implementation | 1d | 2005-02-11 | 2005-02-11 |  | 0d |  | start no earlier than 2005-02-11 |  |  |
| 23 | 1.1.3.2.2 | Location Implementation | 1d | 2005-02-14 | 2005-02-14 | 22 | 0d |  |  |  |  |
| 24 | 1.1.3.2.3 | Robot Class Testing | 1d | 2005-02-15 | 2005-02-15 | 23 | 0d |  |  |  |  |

| ID | WBS | Task | Duration | Start | Finish | Predecessors | Total slack | Free slack | Constraint | Resources | Work |
| --- | --- | --- | --- | --- | --- | --- | --- | --- | --- | --- | --- |
| 25 | 1.1.4 | **Code Review** | 1d? | 2005-02-16 | 2005-02-16 | 15 | 0d |  |  | Mike; Peri; Sean; Joe; Sean W | 40h |
| 26 | 1.1.4.1 | Mapping Implementation Code Review | 1d? | 2005-02-16 | 2005-02-16 |  | 0d |  |  |  |  |
| 27 | 1.2 | **Middleman Server Modifications** | 27d | 2005-01-10 | 2005-02-15 |  | 52d | 0d |  | Mike | 432h |
| 28 | 1.2.1 | **Dummy Robot Emulation Server** | 8d | 2005-01-10 | 2005-01-19 |  | 71d |  |  | Mike | 64h |
| 29 | 1.2.1.1 | Dummy Emulation Server Implementation | 4d | 2005-01-10 | 2005-01-13 |  | 71d | 0d | start no earlier than 2005-01-10 |  |  |
| 30 | 1.2.1.2 | Dummy Emulation Server Testing | 4d | 2005-01-14 | 2005-01-19 | 29 | 71d |  |  |  |  |
| 31 | 1.2.2 | **Middleman Command Processing** | 19d | 2005-01-20 | 2005-02-15 |  | 52d |  |  | Mike | 152h |
| 32 | 1.2.2.1 | Middleman Command Validation Imp | 4d | 2005-01-20 | 2005-01-25 |  | 52d | 0d | start no earlier than 2005-01-20 |  |  |
| 33 | 1.2.2.2 | Middleman Command Validation Testing | 4d | 2005-01-26 | 2005-01-31 | 32 | 52d | 0d |  |  |  |
| 34 | 1.2.2.3 | Middleman Robot Position Polling Imp | 4d | 2005-02-01 | 2005-02-04 | 33 | 52d | 0d |  |  |  |
| 35 | 1.2.2.4 | Middleman Robot Position Polling Testing | 2d | 2005-02-07 | 2005-02-08 | 34 | 52d | 0d |  |  |  |
| 36 | 1.2.2.5 | Middleman Command and Position Integration Testing | 5d | 2005-02-09 | 2005-02-15 | 35 | 52d |  |  |  |  |
| 37 | 1.3 | **Code Review** | 1d? | 2005-02-16 | 2005-02-16 | 27 | 52d |  |  | Mike; Peri; Sean; Joe; Sean W | 13.33h |
| 38 | 1.3.1 | Middleman Server Mod Code Review | 1d? | 2005-02-16 | 2005-02-16 |  | 52d |  |  |  |  |
| 39 | 1.4 | **Web Interface Integration Testing** | 14d | 2005-02-17 | 2005-03-08 | 2 | 0d |  |  | Mike; Peri; Sean; Joe; Sean W | 560h |
| 40 | 1.4.1 | Controls and Mapping to Applet Integration Testing | 7d | 2005-02-17 | 2005-02-25 |  | 0d |  |  |  |  |
| 41 | 1.4.2 | Applet to Middleman Integration Testing | 7d | 2005-02-28 | 2005-03-08 | 40 | 0d |  |  |  |  |
| 42 | 1.5 | **Middleman Integration Testing** | 7d | 2005-03-09 | 2005-03-17 | 39 | 31d |  |  | Mike; Peri | 112h |
| 43 | 1.5.1 | Middleman to Robot Integration Testing | 7d | 2005-03-09 | 2005-03-17 |  | 31d |  |  |  |  |
| 44 | 1.6 | **Aria** | 25d | 2005-01-10 | 2005-02-11 |  | 55d |  |  | Andrew; Mike; Peri | 600h |
| 45 | 1.6.1 | Installation | 7d | 2005-01-10 | 2005-01-18 |  | 55d | 0d | start no earlier than 2005-01-10 |  |  |
| 46 | 1.6.2 | API Implementation | 9d | 2005-01-19 | 2005-01-31 | 45 | 55d | 0d |  |  |  |
| 47 | 1.6.3 | API testing | 9d | 2005-02-01 | 2005-02-11 | 46 | 55d |  |  |  |  |
| 48 | 1.7 | **Usability Testing** | 21d | 2005-03-09 | 2005-04-06 | 39 | 0d |  |  | Peri; Sean | 336h |
| 49 | 1.7.1 | User Interface Prototype | 21d | 2005-03-09 | 2005-04-06 |  | 0d |  |  |  |  |
| 50 | 1.7.2 | Web interface usability testing | 21d | 2005-03-09 | 2005-04-06 |  | 0d |  |  |  |  |

| ID | WBS | Task | Duration | Start | Finish | Predecessors | Total slack | Constraint | Resources | Work |
| --- | --- | --- | --- | --- | --- | --- | --- | --- | --- | --- |
| 51 | 1.8 | **Documentation** | 76d | 2005-01-10 | 2005-04-25 |  | 4d |  | Sean W | 608h |
| 52 | 1.8.1 | Bi-Weekly Documentation updates | 76d | 2005-01-10 | 2005-04-25 |  | 4d | start no earlier than 2005-01-10 |  |  |
| 53 | 1.8.2 | Weekly Website Update | 76d | 2005-01-10 | 2005-04-25 |  | 4d | start no earlier than 2005-01-10 |  |  |
| 54 | 1.9 | **Installation** | 2d? | 2005-04-07 | 2005-04-08 | 48 | 0d |  | Andrew; Mike; Peri | 48h |
| 55 | 1.9.1 | Middleman Server Installation | 2d | 2005-04-07 | 2005-04-08 |  | 0d |  |  |  |
| 56 | 1.9.2 | Applet Installation | 1d? | 2005-04-07 | 2005-04-07 |  | 1d |  |  |  |
| 57 | 1.10 | Buffer Time | 15d | 2005-04-11 | 2005-04-29 | 54 | 0d |  |  |  |
