# Gant1

Schedule from MS Project, 2005-01-10 to 2005-05-06, A marks actual dates.

## Calendars

- Standard: Mon-Fri 08:00-12:00, 13:00-17:00; Sat-Sun off. Exceptions (off unless hours are given): 2005-05-01 08:00-12:00, 13:00-17:00.

## Resources

| Resource |
| --- |
| Peri |
| Peri & Mike |
| Joe & Sean |
| Sean & Mike |
| Mike |
| Sean |
| Joe |
| Sean W |
| Andrew |
| Sean Williams |

## Schedule

| ID | WBS | Task | Duration | Start | Finish | Predecessors | Complete | Remaining | Total slack | Constraint | Resources | Work | Actual work |
| --- | --- | --- | --- | --- | --- | --- | --- | --- | --- | --- | --- | --- | --- |
| 1 | 1 | **ROMP Project** | 86d? | 2005-01-10 A | 2005-05-06 |  | 69% | 26.47d? | 0d |  | Mike; Peri; Sean; Joe; Sean W | 11841.1h | 8235.89h |
| 2 | 1.1 | **Web Interface Implementation** | 35d? | 2005-01-10 A | 2005-02-25 |  | 99% | 0d? | 0d |  | Peri | 2240.8h | 1800.8h |
| 3 | 1.1.1 | **Controls Implementation** | 33d | 2005-01-10 A | 2005-02-23 A |  | 100% |  |  |  |  | 844.8h | 844.8h |
| 4 | 1.1.1.1 | **Pan Control** | 11d | 2005-01-10 A | 2005-01-24 A |  | 100% |  |  |  | Peri | 281.6h | 281.6h |
| 5 | 1.1.1.1.1 | Pan Control Implementation | 7d | 2005-01-10 A | 2005-01-18 A |  | 100% |  |  | start no earlier than 2005-01-10 |  | 56h | 56h |
| 6 | 1.1.1.1.2 | Pan Control Testing | 4d | 2005-01-19 A | 2005-01-24 A | 5 | 100% |  |  | start no earlier than 2005-01-11 |  | 32h | 32h |
| 7 | 1.1.1.2 | **Tilt Control** | 11d | 2005-01-25 A | 2005-02-08 A | 6 | 100% |  |  |  | Peri | 281.6h | 281.6h |
| 8 | 1.1.1.2.1 | Tilt Control Implementation | 7d | 2005-01-25 A | 2005-02-02 A |  | 100% |  |  |  |  | 56h | 56h |
| 9 | 1.1.1.2.2 | Tilt Control Testing | 4d | 2005-02-03 A | 2005-02-08 A | 8 | 100% |  |  |  |  | 32h | 32h |
| 10 | 1.1.1.3 | **Zoom Control** | 11d | 2005-02-09 A | 2005-02-23 A | 9 | 100% |  |  |  | Peri | 281.6h | 281.6h |
| 11 | 1.1.1.3.1 | Zoom Control Implementation | 7d | 2005-02-09 A | 2005-02-17 A |  | 100% |  |  | start no earlier than 2005-01-29 |  | 56h | 56h |
| 12 | 1.1.1.3.2 | Zoom Control Testing | 4d | 2005-02-18 A | 2005-02-23 A | 11 | 100% |  |  |  |  | 32h | 32h |
| 13 | 1.1.2 | **Code Review** | 1d? | 2005-02-24 A | 2005-02-24 A | 3 | 100% |  |  |  | Mike; Peri; Sean; Joe; Sean W | 48h | 48h |
| 14 | 1.1.2.1 | Controls Implementation Code Review | 1d? | 2005-02-24 A | 2005-02-24 A |  | 100% |  |  |  |  | 8h | 8h |
| 15 | 1.1.3 | **Mapping Implementation** | 34d | 2005-01-10 A | 2005-02-24 |  | 99% | 0d | 0d |  | Joe; Sean | 960h | 560h |
| 16 | 1.1.3.1 | **Map Class Implementation** | 28d | 2005-01-10 A | 2005-02-16 A |  | 100% |  |  |  |  | 224h | 224h |
| 17 | 1.1.3.1.1 | Canvas Graphics Implementation | 4d | 2005-01-10 A | 2005-01-13 A |  | 100% |  |  | start no earlier than 2005-01-10 |  | 32h | 32h |
| 18 | 1.1.3.1.2 | Canvas Graphics Testing | 5d | 2005-01-14 A | 2005-01-20 A | 17 | 100% |  |  |  |  | 40h | 40h |
| 19 | 1.1.3.1.3 | Mapping Zoom Implementation | 14d | 2005-01-21 A | 2005-02-09 A | 18 | 100% |  |  |  |  | 112h | 112h |
| 20 | 1.1.3.1.4 | Mapping Zoom Testing | 5d | 2005-02-10 A | 2005-02-16 A | 19 | 100% |  |  |  |  | 40h | 40h |
| 21 | 1.1.3.2 | **Robot Class Implementation** | 10d | 2005-02-11 A | 2005-02-24 A |  | 100% |  |  |  | Joe; Sean | 240h | 80h |
| 22 | 1.1.3.2.1 | Rotation Implementation | 4d | 2005-02-11 A | 2005-02-16 A |  | 100% |  |  | start no earlier than 2005-02-11 |  | 32h | 32h |
| 23 | 1.1.3.2.2 | Location Implementation | 4d | 2005-02-17 A | 2005-02-22 A | 22 | 100% |  |  |  |  | 32h | 32h |
| 24 | 1.1.3.2.3 | Robot Class Testing | 2d | 2005-02-23 A | 2005-02-24 A | 23 | 100% |  |  |  |  | 16h | 16h |

| ID | WBS | Task | Duration | Start | Finish | Predecessors | Complete | Remaining | Total slack | Free slack | Constraint | Resources | Work | Actual work |
| --- | --- | --- | --- | --- | --- | --- | --- | --- | --- | --- | --- | --- | --- | --- |
| 25 | 1.1.4 | **Code Review** | 1d? | 2005-02-25 A | 2005-02-25 A | 15 | 100% |  |  |  |  | Mike; Peri; Sean; Joe; Sean W | 48h | 8h |
| 26 | 1.1.4.1 | Mapping Implementation Code Review | 1d? | 2005-02-25 A | 2005-02-25 A |  | 100% |  |  |  |  |  | 8h | 8h |
| 27 | 1.2 | **Middleman Server Modifications** | 40d | 2005-01-10 A | 2005-03-04 A |  | 100% |  |  |  |  | Mike | 896h | 896h |
| 28 | 1.2.1 | **Dummy Robot Emulation Server** | 8d | 2005-01-10 A | 2005-01-19 A |  | 100% |  |  |  |  | Mike | 128h | 128h |
| 29 | 1.2.1.1 | Dummy Emulation Server Implementation | 4d | 2005-01-10 A | 2005-01-13 A |  | 100% |  |  |  | start no earlier than 2005-01-10 |  | 32h | 32h |
| 30 | 1.2.1.2 | Dummy Emulation Server Testing | 4d | 2005-01-14 A | 2005-01-19 A | 29 | 100% |  |  |  |  |  | 32h | 32h |
| 31 | 1.2.2 | **Middleman Command Processing** | 32d | 2005-01-20 A | 2005-03-04 A |  | 100% |  |  |  |  | Mike | 512h | 512h |
| 32 | 1.2.2.1 | Middleman Command Validation Imp | 7d | 2005-01-20 A | 2005-01-28 A |  | 100% |  |  |  | start no earlier than 2005-01-20 |  | 56h | 56h |
| 33 | 1.2.2.2 | Middleman Command Validation Testing | 7d | 2005-01-31 A | 2005-02-08 A | 32 | 100% |  |  |  |  |  | 56h | 56h |
| 34 | 1.2.2.3 | Middleman Robot Position Polling Imp | 7d | 2005-02-09 A | 2005-02-17 A | 33 | 100% |  |  |  |  |  | 56h | 56h |
| 35 | 1.2.2.4 | Middleman Robot Position Polling Testing | 4d | 2005-02-18 A | 2005-02-23 A | 34 | 100% |  |  |  |  |  | 32h | 32h |
| 36 | 1.2.2.5 | Middleman Command and Position Integration Testing | 7d | 2005-02-24 A | 2005-03-04 A | 35 | 100% |  |  |  |  |  | 56h | 56h |
| 37 | 1.3 | **Code Review** | 1d? | 2005-03-07 | 2005-03-07 | 27 |  |  | 45d |  |  | Mike; Peri; Sean; Joe; Sean W | 72h |  |
| 38 | 1.3.1 | Middleman Server Mod Code Review | 1d? | 2005-03-07 | 2005-03-07 |  |  |  | 45d |  |  |  | 32h |  |
| 39 | 1.4 | **Web Interface Integration Testing** | 14d | 2005-02-28 A | 2005-03-17 A | 2 | 100% |  |  |  |  | Mike; Peri; Sean; Joe; Sean W | 1232h | 1232h |
| 40 | 1.4.1 | Controls and Mapping to Applet Integration Testing | 7d | 2005-02-28 A | 2005-03-08 A |  | 100% |  |  |  |  |  | 56h | 56h |
| 41 | 1.4.2 | Applet to Middleman Integration Testing | 7d | 2005-03-09 A | 2005-03-17 A | 40 | 100% |  |  |  |  |  | 56h | 56h |
| 42 | 1.5 | **Middleman Integration Testing** | 7d | 2005-03-18 | 2005-03-28 | 39 |  |  | 30d |  |  | Mike; Peri | 224h |  |
| 43 | 1.5.1 | Middleman to Robot Integration Testing | 7d | 2005-03-18 | 2005-03-28 |  |  |  | 30d |  |  |  | 112h |  |
| 44 | 1.6 | **Aria** | 35d | 2005-01-10 | 2005-02-25 |  |  |  | 51d |  |  | Andrew; Mike; Peri | 817.93h |  |
| 45 | 1.6.1 | Installation | 7d | 2005-01-10 | 2005-01-18 |  |  |  | 51d | 0d | start no earlier than 2005-01-10 |  | 56h |  |
| 46 | 1.6.2 | API Implementation | 14d | 2005-01-19 | 2005-02-07 | 45 |  |  | 51d | 0d |  |  | 72h |  |
| 47 | 1.6.3 | API testing | 14d | 2005-02-08 | 2005-02-25 | 46 |  |  | 51d |  |  |  | 72h |  |
| 48 | 1.7 | **Usability Testing** | 15d | 2005-03-18 A | 2005-04-07 | 39 | 30% | 10.5d | 22d |  |  | Peri; Sean | 576h | 163.01h |
| 49 | 1.7.1 | User Interface Prototype | 15d | 2005-03-18 A | 2005-04-07 |  | 42% | 8.75d | 22d |  | start no earlier than 2005-03-17 |  | 168h | 70h |
| 50 | 1.7.2 | Web interface usability testing | 10d | 2005-03-25 A | 2005-04-07 |  | 13% | 8.75d | 22d |  | finish no earlier than 2005-04-07 |  | 168h | 21h |

| ID | WBS | Task | Duration | Start | Finish | Predecessors | Complete | Remaining | Total slack | Free slack | Constraint | Resources | Work | Actual work |
| --- | --- | --- | --- | --- | --- | --- | --- | --- | --- | --- | --- | --- | --- | --- |
| 51 | 1.8 | **Documentation** | 86d | 2005-01-10 A | 2005-05-06 |  | 75% | 21.5d | 0d |  |  | Sean W | 2064h | 1548.01h |
| 52 | 1.8.1 | Bi-Weekly Documentation updates | 86d | 2005-01-10 A | 2005-05-06 |  | 75% | 21.5d | 0d |  | start no earlier than 2005-01-10 |  | 688h | 516h |
| 53 | 1.8.2 | Weekly Website Update | 86d | 2005-01-10 A | 2005-05-06 |  | 75% | 21.5d | 0d |  | start no earlier than 2005-01-10 |  | 688h | 516h |
| 54 | 1.9 | **Installation** | 2d? | 2005-04-08 A | 2005-04-11 A | 48 | 100% |  |  |  |  | Andrew; Mike; Peri | 72h | 72h |
| 55 | 1.9.1 | Middleman Server Installation | 2d | 2005-04-08 A | 2005-04-11 A |  | 100% |  |  |  |  |  | 16h | 16h |
| 56 | 1.9.2 | Applet Installation | 1d? | 2005-04-08 A | 2005-04-08 A |  | 100% |  |  |  |  |  | 8h | 8h |
| 57 | 1.10 | Buffer Time | 15d | 2005-04-12 | 2005-05-01 | 54 |  |  | 5d |  |  |  |  |  |
| 59 | 2 | **Video Streaming Design & Implementation** | 39d? | 2005-03-07 A | 2005-04-28 |  | 32% | 26.63d? | 7d |  |  |  |  |  |
| 60 | 2.1 | **Video Streaming Design** | 12d? | 2005-03-07 A | 2005-03-22 A |  | 100% |  |  |  |  |  |  |  |
| 61 | 2.1.1 | MiddleMan Design | 6d? | 2005-03-07 A | 2005-03-14 A |  | 100% |  |  |  | finish no earlier than 2005-03-14 |  |  |  |
| 62 | 2.1.2 | Applet Design | 7d? | 2005-03-14 A | 2005-03-22 A |  | 100% |  |  |  | start no earlier than 2005-03-14 |  |  |  |
| 63 | 2.2 | **Video Streaming Implementation** | 14d? | 2005-03-24 | 2005-04-12 |  |  |  | 19d |  |  |  |  |  |
| 64 | 2.2.1 | MiddleMan Implementation | 8d? | 2005-03-24 | 2005-04-04 |  |  |  | 25d |  | start no earlier than 2005-03-24 |  |  |  |
| 65 | 2.2.2 | Applet Implementation | 7d? | 2005-04-04 | 2005-04-12 |  |  |  | 19d |  | finish no earlier than 2005-04-12 |  |  |  |
| 66 | 2.3 | **Video Streaming Integration & Testing** | 13d? | 2005-04-12 | 2005-04-28 |  |  |  | 7d |  |  |  |  |  |
| 67 | 2.3.1 | Camera to MiddleMan Testing | 6d? | 2005-04-12 | 2005-04-19 |  |  |  | 7d | 0d | finish no earlier than 2005-04-19 |  |  |  |
| 68 | 2.3.2 | MiddleMan to Applet Testing | 7d? | 2005-04-20 | 2005-04-28 |  |  |  | 7d |  |  |  |  |  |
